# Valuación 2a - costo

Schedule from MS Project, 2020-01-01 to 2020-02-20, 6 hours a day, costs in $.

## Calendars

- Estándar: Mon-Fri 10:00-13:00, 15:00-18:00; Sat-Sun off.

## Resources

| Resource | Unit | Rate | Cost per use |
| --- | --- | --- | --- |
| Consultor ext. |  | 250 | 1500 |
| Consultor |  | 150 |  |
| Analista |  | 50 |  |
| Asistente |  | 20 |  |
| Automovil |  | 13.33 | 10 |
| Gasolina | litro | 2 |  |
| Software | licencia | 300 |  |
| Papel | resma | 15 |  |
| Encuadernacion | cuaderno | 50 |  |

## Schedule

| ID | Task | Type | Duration | Start | Finish | Predecessors | Total slack | Free slack | Resources | Work | Cost |
| --- | --- | --- | --- | --- | --- | --- | --- | --- | --- | --- | --- |
| 1 | INICIO | milestone | 0d | 2020-01-01 | 2020-01-01 |  | 0d |  |  |  |  |
| 2 | BUS. INFO |  | 4d | 2020-01-01 | 2020-01-06 | 1 | 0d |  | Analista [200%]; Asistente [400%] | 144h | 4,320 |
| 3 | BUS. INVERSORES |  | 3w | 2020-01-01 | 2020-01-21 | 1 | 11.33d | 0d | Consultor [300%]; Automovil; Gasolina [150 litro] | 360h | 42,010 |
| 4 | ELAB. DIAGNOSTICO |  | 5d | 2020-01-07 | 2020-01-13 | 2 | 20d |  | Consultor [200%]; Analista [400%] | 180h | 15,000 |
| 5 | VALUAR EMP. |  | 1mo | 2020-01-07 | 2020-02-03 | 2 | 0d |  | Consultor ext.; Consultor [300%]; Analista [200%]; Asistente | 840h | 99,900 |
| 6 | SEL. INVERSORES |  | 240min | 2020-01-22 | 2020-01-22 | 3 | 11.33d | 0d | Consultor [200%]; Asistente | 12h | 1,280 |
| 7 | AN. SENSIBILIDAD |  | 5d | 2020-02-04 | 2020-02-10 | 5 | 0d |  | Consultor [200%]; Analista; Software [1 licencia] | 90h | 10,800 |
| 8 | ELAB. INFORMES |  | 8d | 2020-02-11 | 2020-02-20 | 4, 7 | 0d |  | Consultor [200%]; Analista [400%]; Papel [10 resma]; Encuadernacion [5 cuaderno] | 288h | 24,690 |
| 9 | NEGOCIACIÓN |  | 60h | 2020-01-22 | 2020-02-05 | 6 | 11.33d |  | Consultor [300%] | 180h | 27,000 |
| 10 | FIN | milestone | 0d | 2020-02-20 | 2020-02-20 | 8, 9 | 0d |  |  |  |  |
